# Example1

Schedule from MS Project, 2010-12-03 to 2010-12-21.
Civil and Environmental Engineering, UAF

## Calendars

- Standard: Mon-Fri 08:00-12:00, 13:00-17:00; Sat-Sun off.

## Schedule

| ID | Task | Duration | Start | Finish | Predecessors | Total slack | Free slack | Constraint |
| --- | --- | --- | --- | --- | --- | --- | --- | --- |
| 1 | Shut down line | 1d | 2010-12-03 | 2010-12-03 |  | 0d |  | start no earlier than 2010-12-03 |
| 2 | Clean and adjust A | 7d | 2010-12-06 | 2010-12-14 | 1 | 0d |  |  |
| 3 | Start and test A | 3d | 2010-12-15 | 2010-12-17 | 2, 7 | 0d |  |  |
| 4 | Clean and adjust B | 6d | 2010-12-06 | 2010-12-13 | 1 | 1d | 0d |  |
| 5 | Start and test B | 3d | 2010-12-14 | 2010-12-16 | 4, 7 | 1d |  |  |
| 6 | Test system | 2d | 2010-12-20 | 2010-12-21 | 3, 5 | 0d |  |  |
| 7 | Manufacturers rep to site | 2d | 2010-12-06 | 2010-12-07 | 1 | 5d | 4d |  |
